# DoradoBioacoustics2018

Schedule from MS Project, 2018-02-01 to 2018-11-26, A marks actual dates.
MBARI

## Calendars

- Standard: Mon-Fri 08:00-12:00, 13:00-17:00; Sat-Sun off.

## Schedule

| ID | WBS | Task | Type | Duration | Start | Finish | Predecessors | Complete | Remaining | Total slack | Free slack | Constraint |
| --- | --- | --- | --- | --- | --- | --- | --- | --- | --- | --- | --- | --- |
| 1 | 1 | **Sea Days** |  | 21d | 2018-10-26 | 2018-11-26 |  |  |  | 0d |  |  |
| 2 | 1.1 | Test Day 1 | milestone, manual | 0d | 2018-10-26 | 2018-10-26 |  |  |  |  |  |  |
| 3 | 1.2 | Test Day 2 | milestone, manual | 0d | 2018-10-29 | 2018-10-29 |  |  |  |  |  |  |
| 4 | 1.3 | Test Day 3 | milestone, manual | 0d | 2018-11-26 | 2018-11-26 |  |  |  |  |  |  |
| 6 | 2 | **Concept Design** |  | 5d? | 2018-02-01 A | 2018-02-07 |  | 80% | 1d? |  |  |  |
| 7 | 2.1 | Review Functional Requirements |  | 1d | 2018-02-01 A | 2018-02-01 A |  | 100% |  |  |  | start no earlier than 2018-02-01 |
| 8 | 2.2 | Review Derived Requirements |  | 1d | 2018-02-02 A | 2018-02-02 A | 7 | 100% |  |  |  |  |
| 9 | 2.3 | Basic Power Budget |  | 1d | 2018-02-05 A | 2018-02-05 A | 8 | 100% |  |  |  |  |
| 10 | 2.4 | Initial Buoyancy Estimates |  | 1d? | 2018-02-06 | 2018-02-06 | 9 |  |  | 208d |  |  |
| 11 | 2.5 | System Concept Diagram |  | 1d? | 2018-02-07 A | 2018-02-07 A | 10 | 100% |  |  |  |  |
| 12 | 3 | Internal Concept Review | milestone | 1d | 2018-03-06 | 2018-03-06 | 6 |  |  | 188d |  | start no earlier than 2018-03-06 |
| 14 | 4 | **Transducer** |  | 48d | 2018-02-05 | 2018-04-11 |  |  |  | 0d |  |  |
| 15 | 4.1 | Select Transducer |  | 1w | 2018-02-05 | 2018-02-09 | 8 |  |  | 0d |  |  |
| 16 | 4.2 | Specify Cabling |  | 1d | 2018-02-12 | 2018-02-12 | 15 |  |  | 204d |  |  |
| 17 | 4.3 | Order Transducers |  | 1d | 2018-02-12 | 2018-02-12 | 15 |  |  | 162d | 0d |  |
| 18 | 4.4 | Transducer Production |  | 8w | 2018-02-13 | 2018-04-09 | 17 |  |  | 162d | 0d |  |
| 19 | 4.5 | Tank Testing / Acceptance |  | 2d | 2018-04-10 | 2018-04-11 | 18 |  |  | 162d |  |  |
| 21 | 5 | **Design** |  | 49d | 2018-02-12 A | 2018-04-19 |  | 2% | 48.26d | 95d | 0d |  |
| 22 | 5.1 | System Wiring Diagram |  | 1d | 2018-02-12 | 2018-02-12 | 15 |  |  | 0d |  |  |
| 23 | 5.2 | **SBC** |  | 27d | 2018-02-13 A | 2018-03-21 | 22 | 3% | 26.2d | 106d |  |  |
| 24 | 5.2.1 | SBC Requirements |  | 15d | 2018-02-13 A | 2018-03-05 |  | 5% | 14.2d | 106d | 0d | finish no earlier than 2018-03-05 |
| 25 | 5.2.2 | SBC Selection |  | 3d | 2018-03-06 | 2018-03-08 | 24 |  |  | 106d | 0d |  |
| 26 | 5.2.3 | Order Eval SBC |  | 5d | 2018-03-09 | 2018-03-15 | 25 |  |  | 106d | 0d |  |
| 27 | 5.2.4 | Build OS |  | 2d | 2018-03-16 | 2018-03-19 | 26 |  |  | 106d | 0d |  |
| 28 | 5.2.5 | Test SW |  | 2d | 2018-03-20 | 2018-03-21 | 27 |  |  | 106d | 0d |  |

| ID | WBS | Task | Type | Duration | Start | Finish | Predecessors | Total slack | Free slack |
| --- | --- | --- | --- | --- | --- | --- | --- | --- | --- |
| 30 | 5.3 | **Mechanical** |  | 38d | 2018-02-12 | 2018-04-04 | 15 | 106d |  |
| 31 | 5.3.1 | Transducer Horizontal Mounting (x2) |  | 1d | 2018-02-12 | 2018-02-12 |  | 163d | 0d |
| 32 | 5.3.2 | Transducer Downward Mounting (x2) |  | 1d | 2018-02-13 | 2018-02-13 | 31 | 163d |  |
| 33 | 5.3.3 | Chassis Design |  | 2d | 2018-03-22 | 2018-03-23 | 28 | 106d | 0d |
| 34 | 5.3.4 | Housing Design |  | 5d | 2018-03-26 | 2018-03-30 | 33 | 106d | 0d |
| 35 | 5.3.5 | Housing Bracketry |  | 3d | 2018-04-02 | 2018-04-04 | 34 | 106d |  |
| 36 | 5.4 | **Electrical** |  | 33d | 2018-03-06 | 2018-04-19 |  |  |  |
| 37 | 5.4.1 | Select Connectors |  | 2d | 2018-03-06 | 2018-03-07 | 22 | 126d | 32d |
| 38 | 5.4.2 | Battery Pack / Power Supply Design |  | 2w | 2018-03-16 | 2018-03-29 | 26 | 110d | 16d |
| 39 | 5.4.3 | <New Task> | manual | 1d? | 2018-03-06 | 2018-03-06 |  |  |  |
| 40 | 6 | CDR |  | 1d | 2018-04-20 | 2018-04-20 | 21 | 95d | 0d |
| 41 | 7 | **Manufacturing** |  | 60d? | 2018-04-23 | 2018-07-13 | 40 | 95d |  |
| 42 | 7.1 | Order Connectors |  | 12w | 2018-04-23 | 2018-07-13 | 37 | 95d |  |
| 43 | 7.2 | Order Sphere |  | 10w | 2018-04-23 | 2018-06-29 | 37 | 105d |  |
| 44 | 7.3 | Board Layout |  | 2w | 2018-04-23 | 2018-05-04 | 38 | 125d | 0d |
| 45 | 7.4 | Board Fabrication |  | 3w | 2018-05-07 | 2018-05-25 | 44 | 125d | 0d |
| 46 | 7.5 | Board Testing |  | 1w | 2018-05-28 | 2018-06-01 | 45 | 125d |  |
| 47 | 7.6 | Machine Housing |  | 2w | 2018-04-23 | 2018-05-04 |  | 145d |  |
| 48 | 7.7 | Anodize Housing |  | 1w | 2018-04-23 | 2018-04-27 |  | 150d |  |
| 49 | 7.8 | Machine Brackets |  | 1w | 2018-04-23 | 2018-04-27 |  | 150d |  |
